Schedule from MS Project, 2007-04-02 to 2008-07-21.

## Calendars

- Standaard: Mon-Fri 08:30-12:30, 13:00-17:00; Sat-Sun off.

## Schedule

| ID | Task | Type | Duration | Start | Finish | Predecessors | Total slack | Constraint |
| --- | --- | --- | --- | --- | --- | --- | --- | --- |
| 1 | Preliminary design |  | 136d? | 2007-04-02 | 2007-10-08 |  | 0d | start no earlier than 2007-04-02 |
| 2 | Status report on preliminary design | milestone | 1d? | 2007-10-09 | 2007-10-09 | 1 | 0d |  |
| 3 | Design of new modules |  | 28d | 2007-10-10 | 2007-11-16 | 2 | 0d |  |
| 4 | FE technical design review | milestone | 1d? | 2007-11-19 | 2007-11-19 | 3 | 0d |  |
| 5 | Production of prototype |  | 84d | 2007-11-20 | 2008-03-14 | 4 | 0d |  |
| 6 | Delivery of prototype for Virgo test | milestone | 1d? | 2008-03-17 | 2008-03-17 | 5 | 0d |  |
| 7 | Tests of prototype |  | 14d | 2008-03-18 | 2008-04-04 | 6 | 0d |  |
| 8 | Production of final modules |  | 61d | 2008-04-07 | 2008-06-30 | 7 | 0d |  |
| 9 | Delivery of 10 LP modules | milestone | 1d? | 2008-07-01 | 2008-07-01 | 8 | 0d |  |
| 10 | Finish production of HP modules |  | 13d | 2008-07-02 | 2008-07-18 | 9 | 0d |  |
| 11 | Delivery of remaining modules for Virgo+ | milestone | 1d | 2008-07-21 | 2008-07-21 | 10 | 0d |  |
